# BHL_09

Schedule from MS Project, 2009-03-13 to 2009-12-31.
Missouri Botanical Garden

## Calendars

- Standard: Mon-Fri 08:00-12:00, 13:00-17:00; Sat-Sun off.

## Resources

| Resource |
| --- |
| Mike Lichtenberg |
| BHL Execs |
| BHL IC |
| Dissemination Group |
| Chris Moyers |
| Chris Freeland |
| Bianca Lipscomb |
| Martin Kalfatovic |
| Suzanne Pilsk |
| Patrick Leary |
| David Patterson |
| Henning Scholz |
| Connie Rinaldo |
| EOL BIG |
| Cyndy Parr |
| Phil Cryer |
| Ahmed |
| Diane Rielinger |
| Matt Person |
| Bernard Scaife |
| Ryan Schenk |
| Anthony Goddard |
| Joe deVeer |
| Adrian Smales |
| Terry Catapano |
| Cathy Norton |
| Sam @ IA |
| David Shorthouse |
| Vince Smith |
| Simon Rycroft |
| All BHL |
| Tom Garnett |
| Holly Miller |
| John Mignault |
| David Remsen |
| Nancy Gwinn |
| Susan Fraser |
| Michelle Abeln |
| Jason Throm |

## Schedule

| ID | WBS | Task | Type | Duration | Start | Finish | Total slack | Constraint | Resources | Work |
| --- | --- | --- | --- | --- | --- | --- | --- | --- | --- | --- |
| 1 | 1 | **Delivery Dates** |  | 171d? | 2009-03-20 | 2009-11-15 | 34d |  |  |  |
| 2 | 1.1 | BHL Institutional Council (IC) Meeting | milestone | 1d? | 2009-03-20 | 2009-03-20 | 204d | finish no earlier than 2009-03-20 |  |  |
| 3 | 1.2 | EOL Components/Steering Mtg | milestone | 3d? | 2009-04-21 | 2009-04-23 | 180d | start no earlier than 2009-04-21 |  |  |
| 4 | 1.3 | BHL-Europe Kickoff Meeting | milestone | 5d? | 2009-05-11 | 2009-05-15 | 164d | start no earlier than 2009-05-11 |  |  |
| 5 | 1.4 | eBiosphere | milestone | 3d? | 2009-06-01 | 2009-06-03 | 151d | start no earlier than 2009-06-01 |  |  |
| 6 | 1.5 | MacArthur/Sloane Phase 1 Funding completion | milestone | 1d? | 2009-06-30 | 2009-06-30 | 132d | finish no earlier than 2009-06-30 |  |  |
| 7 | 1.6 | TDWG | milestone | 5d? | 2009-11-09 | 2009-11-13 | 34d | start no earlier than 2009-11-09 |  |  |
| 8 | 1.7 | Moore Year 2 Report | milestone | 1d? | 2009-11-13 | 2009-11-15 | 34d | finish no earlier than 2009-11-15 |  |  |
| 9 | 2 | **Hardware Infrastructure** |  | 100d? | 2009-03-16 | 2009-07-31 | 109d |  |  | 9272h |
| 10 | 2.1 | **Redundant Repositories** |  | 100d? | 2009-03-16 | 2009-07-31 | 109d |  |  | 9272h |
| 11 | 2.1.1 | Discuss first repository mirror for immediate short term |  | 34d? | 2009-03-16 | 2009-04-30 | 175d | start no earlier than 2009-03-16 | Tom Garnett; Adrian Smales; Henning Scholz; Chris Freeland; Phil Cryer | 1360h |
| 12 | 2.1.2 | Darwin & DataNet as long term repository mirrors |  | 100d? | 2009-03-16 | 2009-07-31 | 109d | finish no earlier than 2009-07-31 | Tom Garnett; Adrian Smales; Henning Scholz; Chris Freeland; Phil Cryer | 4000h |
| 13 | 2.1.3 | DataNet as dark archive |  | 100d? | 2009-03-16 | 2009-07-31 | 109d | start no earlier than 2009-03-16 | Tom Garnett | 800h |
| 14 | 2.1.4 | BitTorrent for distribution |  | 100d? | 2009-03-16 | 2009-07-31 | 109d | start no earlier than 2009-03-16 | Phil Cryer | 800h |
| 15 | 2.1.5 | Using Fedora with petabox from IA |  | 77d? | 2009-03-16 | 2009-06-30 | 132d | finish no earlier than 2009-06-30 | Phil Cryer; Ahmed; Sam @ IA | 1848h |
| 16 | 2.1.6 | Resolution on SI Hosting |  | 12d? | 2009-03-16 | 2009-03-31 | 197d | start no earlier than 2009-03-16 | Tom Garnett; Chris Freeland | 192h |
| 17 | 2.1.7 | Otis Airbase possibility |  | 34d? | 2009-03-16 | 2009-04-30 | 175d | start no earlier than 2009-03-16 | Cathy Norton | 272h |
| 18 | 2.2 | **Production Mirror Sites** |  | 100d? | 2009-03-16 | 2009-07-31 | 109d |  |  |  |
| 19 | 2.2.1 | SI/Europe/Global |  | 100d? | 2009-03-16 | 2009-07-31 | 109d | start no earlier than 2009-03-16 |  |  |
| 20 | 3 | **Software Infrastructure** |  | 210d? | 2009-03-13 | 2009-12-31 | 0d |  |  | 31664h |
| 21 | 3.1 | Handles implementation |  | 77d? | 2009-03-16 | 2009-06-30 | 132d | start no earlier than 2009-03-16 |  |  |
| 22 | 3.2 | **JP2 Server** |  | 209d? | 2009-03-16 | 2009-12-31 | 0d |  |  | 3536h |
| 23 | 3.2.1 | Integration of new IIPViewer |  | 12d? | 2009-03-16 | 2009-03-31 | 197d | start no earlier than 2009-03-16 | Chris Moyers; Jason Throm | 192h |
| 24 | 3.2.2 | Ongoing Maintenance |  | 209d? | 2009-03-16 | 2009-12-31 | 0d | start no earlier than 2009-03-16 | Phil Cryer; Chris Moyers | 3344h |

| ID | WBS | Task | Duration | Start | Finish | Total slack | Constraint | Resources | Work |
| --- | --- | --- | --- | --- | --- | --- | --- | --- | --- |
| 25 | 3.3 | **Wiki for text correction & markup** | 100d? | 2009-03-16 | 2009-07-31 | 109d |  |  | 3200h |
| 26 | 3.3.1 | Discuss options with Chinese Academy of Science | 100d? | 2009-03-16 | 2009-07-31 | 109d | finish no earlier than 2009-07-31 | Tom Garnett | 800h |
| 27 | 3.3.2 | Evaluate MediaWiki + SemanticWiki for rekeying/crowdsourcing | 100d? | 2009-03-16 | 2009-07-31 | 109d | finish no earlier than 2009-07-31 | Phil Cryer; Chris Moyers; Chris Freeland | 2400h |
| 28 | 3.4 | **PDF generation** | 101d? | 2009-03-13 | 2009-07-31 | 109d |  |  | 4296h |
| 29 | 3.4.1 | Review thumbnails of PDF Generator | 35d? | 2009-03-13 | 2009-04-30 | 175d | start no earlier than 2009-03-13 | Mike Lichtenberg | 280h |
| 30 | 3.4.2 | Review size of MOBOT PDFs | 34d? | 2009-03-16 | 2009-04-30 | 175d | start no earlier than 2009-03-16 | Mike Lichtenberg | 272h |
| 31 | 3.4.3 | Review of metadata captured from articlizing | 100d? | 2009-03-16 | 2009-07-31 | 109d | start no earlier than 2009-03-16 | Mike Lichtenberg; Bianca Lipscomb | 1600h |
| 32 | 3.4.4 | Review open source viewers for Macs | 34d? | 2009-03-16 | 2009-04-30 | 175d | start no earlier than 2009-03-16 | Mike Lichtenberg; Chris Freeland | 544h |
| 33 | 3.4.5 | Determine better approach for OCR in PDFs | 100d? | 2009-03-16 | 2009-07-31 | 109d | start no earlier than 2009-03-16 | Mike Lichtenberg; Chris Freeland | 1600h |
| 34 | 3.5 | User accounts | 100d? | 2009-03-16 | 2009-07-31 | 109d | start no earlier than 2009-03-16 |  |  |
| 35 | 3.6 | **Improvement of dedupe/bid tools** | 100d? | 2009-03-16 | 2009-07-31 | 109d |  |  | 5120h |
| 36 | 3.6.1 | Quick fixes for Serials Bid List | 34d? | 2009-03-16 | 2009-04-30 | 175d | start no earlier than 2009-03-16 | Bernard Scaife; Matt Person; Suzanne Pilsk; Michelle Abeln | 1088h |
| 37 | 3.6.2 | Inclusion of content in portal/ingests | 77d? | 2009-03-16 | 2009-06-30 | 132d | start no earlier than 2009-03-16 |  |  |
| 38 | 3.6.3 | Expanded redevelopment for BHL Europe | 100d? | 2009-03-16 | 2009-07-31 | 109d | start no earlier than 2009-03-16 |  |  |
| 39 | 3.6.4 | Task force to define requirements | 34d? | 2009-03-16 | 2009-04-30 | 175d | start no earlier than 2009-03-16 | Bianca Lipscomb; Diane Rielinger; Matt Person; Bernard Scaife; Ryan Schenk; Joe deVeer | 1632h |
| 40 | 3.6.5 | Review Open Library's dedupe algorithm | 100d? | 2009-03-16 | 2009-07-31 | 109d | start no earlier than 2009-03-16 | Mike Lichtenberg; Suzanne Pilsk; Chris Freeland | 2400h |
| 41 | 3.7 | **Management of Specialists' Bibliographies** | 34d? | 2009-03-16 | 2009-04-30 | 175d |  |  | 3264h |
| 42 | 3.7.1 | Evaluate Falx | 34d? | 2009-03-16 | 2009-04-30 | 175d | start no earlier than 2009-03-16 | Phil Cryer; Chris Freeland; Chris Moyers | 816h |
| 43 | 3.7.2 | Determine shared vision for managing bibliographies | 34d? | 2009-03-16 | 2009-04-30 | 175d | start no earlier than 2009-03-16 | Chris Freeland; David Shorthouse; Vince Smith; Simon Rycroft; Cyndy Parr; David Patterson | 1632h |
| 44 | 3.7.3 | Gather test groups & use cases, including ZooBank | 34d? | 2009-03-16 | 2009-04-30 | 175d | start no earlier than 2009-03-16 | Tom Garnett; Chris Freeland; Bianca Lipscomb | 816h |
| 45 | 3.8 | **Open Source ILS front end** | 100d? | 2009-03-16 | 2009-07-31 | 109d |  |  |  |
| 46 | 3.8.1 | Summer Library student? | 100d? | 2009-03-16 | 2009-07-31 | 109d | start no earlier than 2009-03-16 |  |  |
| 47 | 3.9 | **Article Repository** | 100d? | 2009-03-16 | 2009-07-31 | 109d |  |  | 12248h |
| 48 | 3.9.1 | Fedora backend | 100d? | 2009-03-16 | 2009-07-31 | 109d | start no earlier than 2009-03-16 |  |  |
| 49 | 3.9.2 | Content from BHL | 100d? | 2009-03-16 | 2009-07-31 | 109d | start no earlier than 2009-03-16 |  |  |

Notes:
- 35: Included in BHL Europe Bid

| ID | WBS | Task | Duration | Start | Finish | Total slack | Constraint | Resources | Work |
| --- | --- | --- | --- | --- | --- | --- | --- | --- | --- |
| 50 | 3.9.3 | **Assigning DOIs** | 77d? | 2009-03-16 | 2009-06-30 | 132d |  |  | 1848h |
| 51 | 3.9.3.1 | Identify exemplar titles for Proof of Concept | 77d? | 2009-03-16 | 2009-06-30 | 132d | finish no earlier than 2009-06-30 | Chris Freeland; Mike Lichtenberg; David Shorthouse | 1848h |
| 52 | 3.9.4 | Combined search across Article Repository & Portal | 100d? | 2009-03-16 | 2009-07-31 | 109d | start no earlier than 2009-03-16 | Phil Cryer; Mike Lichtenberg; Chris Moyers; Chris Freeland | 3200h |
| 53 | 3.9.5 | Identify the connection of BHL Portal titles & Articles | 100d? | 2009-03-16 | 2009-07-31 | 109d | start no earlier than 2009-03-16 | Phil Cryer; Mike Lichtenberg; Chris Moyers; Chris Freeland | 3200h |
| 54 | 3.9.6 | Can Biblio extract XMP from PDFs/docs | 100d? | 2009-03-16 | 2009-07-31 | 109d | finish no earlier than 2009-07-31 | Phil Cryer; Chris Moyers; Chris Freeland; Mike Lichtenberg; Suzanne Pilsk | 4000h |
| 55 | 4 | **Web User Interface** | 209d? | 2009-03-16 | 2009-12-31 | 0d |  |  | 19216h |
| 56 | 4.1 | **BHL Admin** | 209d? | 2009-03-16 | 2009-12-31 | 0d |  |  | 1672h |
| 57 | 4.1.1 | Review portal editing needs | 209d? | 2009-03-16 | 2009-12-31 | 0d | start no earlier than 2009-03-16 | All BHL | 1672h |
| 58 | 4.1.2 | RSS feed of record changes | 100d? | 2009-03-16 | 2009-07-31 | 109d | start no earlier than 2009-03-16 | Mike Lichtenberg | 800h |
| 59 | 4.1.3 | Tracking, logging of changes | 100d? | 2009-03-16 | 2009-07-31 | 109d | start no earlier than 2009-03-16 | Mike Lichtenberg | 800h |
| 60 | 4.2 | **Adding new MARC records to Portal** | 100d? | 2009-03-16 | 2009-07-31 | 109d |  |  | 2400h |
| 61 | 4.2.1 | Pointing two titles to same scan; describing one vol as serial & monographic series | 100d? | 2009-03-16 | 2009-07-31 | 109d | start no earlier than 2009-03-16 | Mike Lichtenberg; Suzanne Pilsk; Diane Rielinger | 2400h |
| 62 | 4.3 | Layout/Redesign | 77d? | 2009-03-16 | 2009-06-30 | 132d | start no earlier than 2009-03-16 |  |  |
| 63 | 4.4 | **Internationalization** | 100d? | 2009-03-16 | 2009-07-31 | 109d |  |  |  |
| 64 | 4.4.1 | Multiple Languages | 100d? | 2009-03-16 | 2009-07-31 | 109d | start no earlier than 2009-03-16 |  |  |
| 65 | 4.5 | **Review Search & Indexing** | 100d? | 2009-03-16 | 2009-07-31 | 109d |  |  | 6400h |
| 66 | 4.5.1 | MARC-level | 100d? | 2009-03-16 | 2009-07-31 | 109d | start no earlier than 2009-03-16 | Phil Cryer; Chris Moyers; Chris Freeland; Mike Lichtenberg | 3200h |
| 67 | 4.5.2 | Full Text | 100d? | 2009-03-16 | 2009-07-31 | 109d | start no earlier than 2009-03-16 | Phil Cryer; Chris Moyers; Chris Freeland; Mike Lichtenberg | 3200h |
| 68 | 4.6 | **FlipBook enhancements** | 77d? | 2009-03-16 | 2009-06-30 | 132d |  |  | 4312h |
| 69 | 4.6.1 | Work with LC/IA on modular approach | 77d? | 2009-03-16 | 2009-06-30 | 132d | finish no earlier than 2009-06-30 | Martin Kalfatovic; Chris Freeland; Joe deVeer; John Mignault | 2464h |
| 70 | 4.6.2 | Incorporate FlipBook into BHL beta | 12d? | 2009-03-16 | 2009-03-31 | 197d | start no earlier than 2009-03-16 |  |  |
| 71 | 4.6.3 | Revisit delivery of thumbnails for browsing | 77d? | 2009-03-16 | 2009-06-30 | 132d | finish no earlier than 2009-06-30 | Mike Lichtenberg; Chris Moyers; Phil Cryer | 1848h |
| 72 | 4.7 | Link BHL bibliography to EOL species pages | 100d? | 2009-03-16 | 2009-07-31 | 109d | start no earlier than 2009-03-16 | Mike Lichtenberg; Patrick Leary | 1600h |
| 73 | 4.8 | Separate out monographs/journals | 34d? | 2009-03-16 | 2009-04-30 | 175d | start no earlier than 2009-03-16 |  |  |
| 74 | 4.9 | Review existing search interface to make more article-friendly | 77d? | 2009-03-16 | 2009-06-30 | 132d | finish no earlier than 2009-06-30 | Mike Lichtenberg; Chris Freeland | 1232h |

Notes:
- 56: Core functionality in hand, need more user feedback

| ID | WBS | Task | Duration | Start | Finish | Total slack | Constraint | Resources | Work |
| --- | --- | --- | --- | --- | --- | --- | --- | --- | --- |
| 75 | 5 | **Data Mining** | 165d? | 2009-03-16 | 2009-10-30 | 44d |  |  | 26272h |
| 76 | 5.1 | **Automated Markup** | 100d? | 2009-03-16 | 2009-07-31 | 109d |  |  | 1616h |
| 77 | 5.1.1 | Investigate partners for research grant | 100d? | 2009-03-16 | 2009-07-31 | 109d | start no earlier than 2009-03-16 | Tom Garnett | 800h |
| 78 | 5.1.2 | Discuss NLM procedures with George Toma | 34d? | 2009-03-16 | 2009-04-30 | 175d | start no earlier than 2009-03-16 | Cathy Norton; Holly Miller | 544h |
| 79 | 5.1.3 | Resume discussions with reCAPTCHA | 34d? | 2009-03-16 | 2009-04-30 | 175d | start no earlier than 2009-03-16 | Chris Freeland | 272h |
| 80 | 5.2 | Run TF2J against gray names in BHL | 100d? | 2009-03-16 | 2009-07-31 | 109d | start no earlier than 2009-03-16 | Ahmed; Mike Lichtenberg | 1600h |
| 81 | 5.3 | Plan Drupal module for TF2J | 100d? | 2009-03-16 | 2009-07-31 | 109d | start no earlier than 2009-03-16 | Chris Freeland; Chris Moyers; Ryan Schenk; Ahmed; Phil Cryer | 4000h |
| 82 | 5.4 | Report on evaluation of TF2J | 12d? | 2009-03-16 | 2009-03-31 | 197d | start no earlier than 2009-03-16 | Cathy Norton; Ahmed | 192h |
| 83 | 5.5 | Work with IA on techniques to identify illustrations | 100d? | 2009-03-16 | 2009-07-31 | 109d | start no earlier than 2009-03-16 | Mike Lichtenberg; Chris Freeland | 1600h |
| 84 | 5.6 | Investigate techniques for place name searching/mining | 165d? | 2009-03-16 | 2009-10-30 | 44d | start no earlier than 2009-03-16 | Ahmed; Phil Cryer; Mike Lichtenberg; Chris Freeland; Chris Moyers | 6600h |
| 85 | 5.7 | **Enhance usability of Taxonomic Intelligence** | 77d? | 2009-03-16 | 2009-06-30 | 132d |  |  | 2232h |
| 86 | 5.7.1 | BHL describe high level description of needs into Jira | 12d? | 2009-03-16 | 2009-03-31 | 197d | start no earlier than 2009-03-16 | Tom Garnett; Chris Freeland | 192h |
| 87 | 5.7.2 | Organize meeting around NameFinding | 77d? | 2009-03-16 | 2009-06-30 | 132d | start no earlier than 2009-03-16 | Tom Garnett; David Patterson; Chris Freeland | 1848h |
| 88 | 5.7.3 | BHL describe needs for nomenclatural acts into Jira | 12d? | 2009-03-16 | 2009-03-31 | 197d | start no earlier than 2009-03-16 | Tom Garnett; Chris Freeland | 192h |
| 89 | 5.8 | **Synonymized Data mining** | 100d? | 2009-03-16 | 2009-07-31 | 109d |  |  | 7200h |
| 90 | 5.8.1 | EOL API development | 100d? | 2009-03-16 | 2009-07-31 | 109d | start no earlier than 2009-03-16 | Patrick Leary; Phil Cryer; Mike Lichtenberg; Chris Freeland; Chris Moyers | 4000h |
| 91 | 5.8.2 | Common Name Search | 100d? | 2009-03-16 | 2009-07-31 | 109d | start no earlier than 2009-03-16 | EOL BIG; Phil Cryer; Mike Lichtenberg; Chris Freeland | 3200h |
| 92 | 5.9 | Export names in each item to XML on filesystem | 77d? | 2009-03-16 | 2009-06-30 | 132d | start no earlier than 2009-03-16 | Mike Lichtenberg; Phil Cryer | 1232h |
| 93 | 6 | **Services** | 165d? | 2009-03-16 | 2009-10-30 | 44d |  |  | 12712h |
| 94 | 6.1 | **Data Exports** | 100d? | 2009-03-16 | 2009-07-31 | 109d |  |  | 3472h |
| 95 | 6.1.1 | Enhance Data Export with REST, other services | 100d? | 2009-03-16 | 2009-07-31 | 109d | start no earlier than 2009-03-16 | Phil Cryer; Mike Lichtenberg; Chris Moyers; Chris Freeland | 3200h |
| 96 | 6.1.2 | Evaluate exports for incorporation into ViTaL/Falx | 34d? | 2009-03-16 | 2009-04-30 | 175d | start no earlier than 2009-03-16 | Bernard Scaife | 272h |
| 97 | 6.2 | **Resolvers** | 165d? | 2009-03-16 | 2009-10-30 | 44d |  |  | 7920h |
| 98 | 6.2.1 | Titles | 165d? | 2009-03-16 | 2009-10-30 | 44d | start no earlier than 2009-03-16 | Chris Freeland; John Mignault; David Remsen | 3960h |
| 99 | 6.2.2 | Citations | 165d? | 2009-03-16 | 2009-10-30 | 44d | start no earlier than 2009-03-16 | Chris Freeland; John Mignault; David Remsen | 3960h |

Notes:
- 97: Emerging work; have supplemental request to work on this

| ID | WBS | Task | Duration | Start | Finish | Total slack | Constraint | Resources | Work |
| --- | --- | --- | --- | --- | --- | --- | --- | --- | --- |
| 100 | 6.3 | **LSIDs** | 165d? | 2009-03-16 | 2009-10-30 | 44d |  |  | 1320h |
| 101 | 6.3.1 | Review Rich Pyle/Zoobank use | 165d? | 2009-03-16 | 2009-10-30 | 44d | start no earlier than 2009-03-16 | Chris Freeland | 1320h |
| 102 | 7 | **Content** | 100d? | 2009-03-16 | 2009-07-31 | 109d |  |  | 15352h |
| 103 | 7.1 | Review diacritics issues for MCZ, SIL, NYBG | 34d? | 2009-03-16 | 2009-04-30 | 175d | start no earlier than 2009-03-16 | Mike Lichtenberg | 272h |
| 104 | 7.2 | IA Page Insertion development & revision in portal | 34d? | 2009-03-16 | 2009-04-30 | 175d | start no earlier than 2009-03-16 | Mike Lichtenberg; Tom Garnett; Cathy Norton | 816h |
| 105 | 7.3 | Review/revise BHL Digitization Specs on Google Docs | 34d? | 2009-03-16 | 2009-04-30 | 175d | start no earlier than 2009-03-16 | Martin Kalfatovic; Chris Freeland; Bernard Scaife; Mike Lichtenberg; Adrian Smales | 1360h |
| 106 | 7.4 | **Content Selection & Prioritization** | 77d? | 2009-03-16 | 2009-06-30 | 132d |  |  | 3696h |
| 107 | 7.4.1 | Index Animalium | 77d? | 2009-03-16 | 2009-06-30 | 132d | finish no earlier than 2009-06-30 | Suzanne Pilsk; Bianca Lipscomb; Patrick Leary | 1848h |
| 108 | 7.4.2 | TL2 | 77d? | 2009-03-16 | 2009-06-30 | 132d | finish no earlier than 2009-06-30 | Suzanne Pilsk; Bianca Lipscomb; Patrick Leary | 1848h |
| 109 | 7.5 | Classification of content digitized by ClassificationBank,others | 100d? | 2009-03-16 | 2009-07-31 | 109d | finish no earlier than 2009-07-31 | Mike Lichtenberg; Chris Freeland; Bianca Lipscomb; EOL BIG | 3200h |
| 110 | 7.6 | **Content Ingest** | 100d? | 2009-03-16 | 2009-07-31 | 109d |  |  | 4376h |
| 111 | 7.6.1 | Evaluate ingest of AnimalBase into Biblio via OAI | 34d? | 2009-03-16 | 2009-04-30 | 175d | start no earlier than 2009-03-16 | Phil Cryer; Chris Moyers; Chris Freeland | 816h |
| 112 | 7.6.2 | Define METS profile for ingest | 100d? | 2009-03-16 | 2009-07-31 | 109d | start no earlier than 2009-03-16 | Chris Freeland; Mike Lichtenberg; Terry Catapano | 2400h |
| 113 | 7.6.3 | **IA-affiliated scanning** | 77d? | 2009-03-16 | 2009-06-30 | 132d |  |  | 616h |
| 114 | 7.6.3.1 | Sample from CDL & dedupe against BHL | 77d? | 2009-03-16 | 2009-06-30 | 132d | finish no earlier than 2009-06-30 | Mike Lichtenberg | 616h |
| 115 | 7.6.4 | **Content from other repositories** | 100d? | 2009-03-16 | 2009-07-31 | 109d |  |  | 544h |
| 116 | 7.6.4.1 | Create wiki page to document known projects/parters | 34d? | 2009-03-16 | 2009-04-30 | 175d | start no earlier than 2009-03-16 | Tom Garnett; Bianca Lipscomb | 544h |
| 117 | 7.6.4.2 | Ingest Content | 100d? | 2009-03-16 | 2009-07-31 | 109d | start no earlier than 2009-03-16 |  |  |
| 118 | 7.7 | Adding new derivatives (TaxonX, etc.) | 77d? | 2009-03-16 | 2009-06-30 | 132d | start no earlier than 2009-03-16 |  |  |
| 119 | 7.8 | EOL LifeDesk/Article Repository Interactions | 34d? | 2009-03-16 | 2009-04-30 | 175d | start no earlier than 2009-03-16 | Phil Cryer; Chris Freeland; Chris Moyers; Bianca Lipscomb; EOL BIG; Cyndy Parr | 1632h |
| 120 | 8 | **Administrative Tasks** | 209d? | 2009-03-16 | 2009-12-31 | 0d |  |  | 21272h |
| 121 | 8.1 | Set expectations for retrospective portal cleanup | 12d? | 2009-03-16 | 2009-03-31 | 197d | finish no earlier than 2009-03-31 | BHL Execs; BHL IC | 192h |
| 122 | 8.2 | Write best practice guide for complex bibliographic items used by biodiversity scholars | 34d? | 2009-03-16 | 2009-04-30 | 175d | start no earlier than 2009-03-16 | Suzanne Pilsk; Tom Garnett; Matt Person; Bernard Scaife | 1088h |
| 123 | 8.3 | Determine data harmonization strategy (if any) with IA | 100d? | 2009-03-16 | 2009-07-31 | 109d | start no earlier than 2009-03-16 | BHL Execs | 800h |
| 124 | 8.4 | Survey BHL-Europe participants | 34d? | 2009-03-16 | 2009-04-30 | 175d | start no earlier than 2009-03-16 | Tom Garnett; Henning Scholz | 544h |
| 125 | 8.5 | Investigate Roadmap with Zotero/Omeka | 34d? | 2009-03-16 | 2009-04-30 | 175d | start no earlier than 2009-03-16 | Martin Kalfatovic | 272h |
| 126 | 8.6 | Reconstitute new Collections Group | 34d? | 2009-03-16 | 2009-04-30 | 175d | start no earlier than 2009-03-16 | BHL Execs; Bianca Lipscomb | 544h |

Notes:
- 118: Don't have infrastructure to support yet

| ID | WBS | Task | Duration | Start | Finish | Total slack | Constraint | Resources | Work |
| --- | --- | --- | --- | --- | --- | --- | --- | --- | --- |
| 127 | 8.7 | **Actions taken by Dissemination Group** | 209d? | 2009-03-16 | 2009-12-31 | 0d |  | BHL Execs | 6088h |
| 128 | 8.7.1 | Creation of Dissemination Group | 12d? | 2009-03-16 | 2009-03-31 | 197d | start no earlier than 2009-03-16 |  |  |
| 129 | 8.7.2 | Outreach for PDF articlizing | 34d? | 2009-03-16 | 2009-04-30 | 175d | start no earlier than 2009-03-16 | Dissemination Group | 272h |
| 130 | 8.7.3 | Gather user feedback on portal development | 100d? | 2009-03-16 | 2009-07-31 | 109d | start no earlier than 2009-03-16 | Dissemination Group | 800h |
| 131 | 8.7.4 | Add more links from Wikipedia into BHL | 209d? | 2009-03-16 | 2009-12-31 | 0d | start no earlier than 2009-03-16 | Dissemination Group | 1672h |
| 132 | 8.7.5 | Investigate new Wikipedia pages for BHL titles | 209d? | 2009-03-16 | 2009-12-31 | 0d | start no earlier than 2009-03-16 | Dissemination Group | 1672h |
| 133 | 8.8 | **Key Dates & Milestones** | 209d? | 2009-03-16 | 2009-12-31 | 0d |  |  | 1768h |
| 134 | 8.8.1 | Chris creates wiki pages | 12d? | 2009-03-16 | 2009-03-31 | 197d | start no earlier than 2009-03-16 | Chris Freeland | 96h |
| 135 | 8.8.2 | Staff updates as needed | 209d? | 2009-03-16 | 2009-12-31 | 0d | start no earlier than 2009-03-16 | All BHL | 1672h |
| 136 | 8.9 | eISBN/OCLC numbers for new digital manifestations | 100d? | 2009-03-16 | 2009-07-31 | 109d | start no earlier than 2009-03-16 | Martin Kalfatovic; Suzanne Pilsk | 1600h |
| 137 | 8.10 | **Commercial Opportunities** | 12d? | 2009-03-16 | 2009-03-31 | 197d |  |  | 288h |
| 138 | 8.10.1 | **One page list of ideas in Sustainability Plan** | 12d? | 2009-03-16 | 2009-03-31 | 197d |  | Tom Garnett | 288h |
| 139 | 8.10.1.1 | Kirtas | 12d? | 2009-03-16 | 2009-03-31 | 197d | start no earlier than 2009-03-16 | Tom Garnett | 96h |
| 140 | 8.10.1.2 | Abebooks | 12d? | 2009-03-16 | 2009-03-31 | 197d | start no earlier than 2009-03-16 | Tom Garnett | 96h |
| 141 | 8.11 | **Form BHL Tech Committee** | 77d? | 2009-03-16 | 2009-06-30 | 132d |  |  | 2040h |
| 142 | 8.11.1 | Set up tech listserv | 12d? | 2009-03-16 | 2009-03-31 | 197d | finish no earlier than 2009-03-31 | Phil Cryer; Chris Freeland | 192h |
| 143 | 8.11.2 | Consolidate listservs at Smithsonian | 77d? | 2009-03-16 | 2009-06-30 | 132d | start no earlier than 2009-03-16 | Bianca Lipscomb; Suzanne Pilsk; Chris Freeland | 1848h |
| 144 | 8.12 | EOL & BHL-E discuss citizen outreach/selection demands | 164d? | 2009-05-18 | 2009-12-31 | 0d | finish no earlier than 2009-12-31 | Tom Garnett; David Patterson; Henning Scholz | 3936h |
| 145 | 8.13 | ECDL Meeting Abstract | 5d? | 2009-03-16 | 2009-03-21 | 204d | finish no earlier than 2009-03-21 | BHL Execs | 40h |
| 146 | 8.14 | eBiosphere Strategy | 55d? | 2009-03-16 | 2009-05-29 | 154d | start no earlier than 2009-03-16 | BHL Execs | 440h |
| 147 | 8.15 | FAQ on wiki for common user complaints | 34d? | 2009-03-16 | 2009-04-30 | 175d | start no earlier than 2009-03-16 | Martin Kalfatovic; Chris Freeland; Connie Rinaldo; All BHL | 1088h |
| 148 | 8.16 | Policy discussion re: copyright/use of Article Repository | 34d? | 2009-03-16 | 2009-04-30 | 175d | start no earlier than 2009-03-16 | BHL Execs; BHL IC | 544h |
